# Ajagraafik_Rapla_I_20.03.24

Schedule from MS Project, 2024-09-11 to 2028-01-04, status date 2024-02-20.

## Calendars

- Standard: Mon-Fri 08:00-12:00, 13:00-17:00; Sat-Sun off. Exceptions (off unless hours are given): 2024-02-24 to 2026-02-24 (Iseseisvuspäev, recurring), 2024-05-01 to 2027-05-01 (Kevadpüha, recurring), 2024-06-23 to 2027-06-23 (Võidupüha, recurring), 2024-06-24 to 2027-06-24 (Jaanipäev, recurring), 2024-08-20 to 2027-08-20 (Taasiseseivusmispäev, recurring), 2024-12-24 to 2026-12-24 (Jõululaupäev, recurring), 2024-12-25 to 2026-12-25 (Esimene jõulupüha, recurring), 2024-12-26 to 2026-12-26 (Teine jõulupüha, recurring), 2025-01-01 to 2027-01-01 (Uusaasta, recurring), 2025-04-18 (Suur reede), 2026-04-03 08:00-12:00, 13:00-17:00 (Suur reede), 2027-03-27 (Suur reede).

## Resources

| Resource |
| --- |
| Projekteerija |
| Ekskavaator 1 |
| Veomasin 1 |
| Veomasin 2 |
| Veomasin 3 |
| Veomasin 4 |
| Veomasin 5 |
| Veomasin 6 |
| Veomasin 7 |
| Rull 3 |
| Buldooser 3 |
| Rajatiste meeskond 1 |
| Teede meeskond 2 |
| Rull 1 |
| Buldooser 2 |
| Buldooser 1 |
| Rull 2 |
| Veomasin 8 |
| Veomasin 9 |
| Veomasin 10 |
| Ekskavaator 2 |
| Frees |
| Asfalteerijad |
| ATV |
| Rajatiste meeskond 2 |
| Ekskavaator 4 |
| Buldooser 4 |
| Veomasin 22 |
| Veomasin 21 |
| Veomasin 23 |
| Veomasin 24 |
| Veomasin 25 |
| Teede meeskond 1 |
| Ekskavaator 5 |
| Veomasin 11 |
| Veomasin 12 |
| Veomasin 13 |
| Veomasin 14 |
| Veomasin 15 |
| Veomasin 16 |
| Ekskavaator 7 |
| Buldooser 5 |
| Rull 4 |
| Veomasin 17 |
| Veomasin 18 |
| Veomasin 19 |
| Veomasin 20 |
| Buldooser 6 |
| Teede meeskond 4 |
| Rull 5 |
| Buldooser 7 |
| Teede meeskond 3 |
| Ekskavaator 3 |
| Veomasin 26 |
| Veomasin 27 |
| Veomasin 28 |
| Veomasin 29 |
| Veomasin 30 |
| Ekskavaator 6 |
| Ekskavaator 8 |
| Teede meeskond 5 |
| Veomasin 31 |
| Veomasin 32 |
| Veomasin 33 |
| Veomasin 34 |
| Veomasin 35 |
| Ekskavaator 9 |
| Ekskavaator 10 |

## Schedule

| ID | WBS | Task | Type | Duration | Start | Finish | Predecessors | Total slack | Free slack | Constraint |
| --- | --- | --- | --- | --- | --- | --- | --- | --- | --- | --- |
| 1 | 1 | RB Harju II põhitrass | manual | 840d | 2024-09-11 | 2028-01-04 |  |  |  |  |
| 2 | 2 | **Kalmari tee** |  | 13d | 2025-04-14 | 2025-05-02 |  | 679d |  |  |
| 3 | 2.1 | Kalmari tee truubi vahetus |  | 4d | 2025-04-14 | 2025-04-17 |  | 679d | 0d | start no earlier than 2025-04-14 |
| 4 | 2.2 | Rae peakraavi eesvoolude puhastamine |  | 9d | 2025-04-21 | 2025-05-02 | 3 | 679d |  |  |
